# pla_suivi1

Schedule from MS Project, 2002-10-21 to 2002-12-05, A marks actual dates.
sans

## Calendars

- Standard: Mon-Fri 08:00-12:00, 13:00-17:00; Sat-Sun off.

## Resources

| Resource |
| --- |
| RVI |
| FBI |
| LMA |
| ABA |

## Schedule

| ID | WBS | Task | Duration | Start | Finish | Predecessors | Complete | Remaining | Baseline start | Baseline finish | Baseline duration | Total slack | Free slack | Constraint | Resources | Work | Actual work |
| --- | --- | --- | --- | --- | --- | --- | --- | --- | --- | --- | --- | --- | --- | --- | --- | --- | --- |
| 2 | 1 | **Produit OEDL** | 32.5d? | 2002-10-21 A | 2002-12-04 |  | 11% | 28.84d? | 2002-10-21 | 2002-11-29 | 30d? | 2.5d |  |  |  | 1732h | 148h |
| 3 | 1.1 | **IHM** | 5d? | 2002-10-21 A | 2002-10-25 A |  | 100% |  | 2002-10-21 | 2002-10-25 | 5d? |  |  |  |  | 28h | 28h |
| 4 | 1.1.1 | Codage IHM Eval | 1.5d? | 2002-10-21 A | 2002-10-22 A |  | 100% |  | 2002-10-21 | 2002-10-22 | 1.5d? |  |  | start no earlier than 2002-10-21 | RVI | 12h | 12h |
| 5 | 1.1.2 | Intégration des IHM | 2d? | 2002-10-24 A | 2002-10-25 A | 4 | 100% |  | 2002-10-24 | 2002-10-25 | 2d? |  |  | start no earlier than 2002-10-24 | FBI | 16h | 16h |
| 6 | 1.2 | **CVS** | 15d? | 2002-10-21 A | 2002-11-08 |  | 50% | 7.5d? | 2002-11-04 | 2002-11-08 | 5d? | 20d |  |  |  | 80h | 40h |
| 7 | 1.2.1 | Etude CVS | 5d? | 2002-10-21 A | 2002-10-25 A |  | 100% |  |  |  |  |  |  | start no earlier than 2002-10-21 | RVI | 40h | 40h |
| 8 | 1.2.2 | Installation CVS | 4d | 2002-11-04 | 2002-11-07 |  |  |  | 2002-11-04 | 2002-11-07 | 4d | 19d | 0d | start no earlier than 2002-11-04 | FBI | 32h |  |
| 9 | 1.2.3 | Mettre le projet sur CVS | 1d? | 2002-11-08 | 2002-11-08 | 8 |  |  | 2002-11-08 | 2002-11-08 | 1d? | 19d |  |  | FBI | 8h |  |
| 10 | 1.3 | **Management du développement** | 28d? | 2002-10-21 A | 2002-11-27 |  | 43% | 15.83d? | 2002-10-21 | 2002-11-27 | 28d? | 7d |  |  |  | 228h | 40h |
| 11 | 1.3.1 | Processus de management + fichier excel | 4d? | 2002-10-21 A | 2002-10-24 A |  | 100% |  | 2002-10-21 | 2002-10-24 | 4d? |  |  | start no earlier than 2002-10-21 | ABA | 32h | 32h |
| 12 | 1.3.2 | Vérification du processus | 1d? | 2002-10-25 A | 2002-10-25 A | 11 | 100% |  | 2002-10-25 | 2002-10-25 | 1d? |  |  | start no earlier than 2002-10-25 | LMA | 8h | 8h |
| 13 | 1.3.3 | Rédaction intial | 2.5d? | 2002-11-04 | 2002-11-06 | 12 |  |  | 2002-11-04 | 2002-11-06 | 2.5d? | 17.5d | 0d | start no earlier than 2002-11-04 | RVI; FBI; LMA | 60h |  |
| 14 | 1.3.4 | Suivi | 1d? | 2002-11-06 | 2002-11-07 | 13 |  |  | 2002-11-06 | 2002-11-07 | 1d? | 17.5d | 3.5d |  | RVI; FBI; LMA; ABA | 32h |  |
| 15 | 1.3.5 | Suivi | 1d? | 2002-11-13 | 2002-11-13 | 14 |  |  | 2002-11-13 | 2002-11-13 | 1d? | 14d | 4d | start no earlier than 2002-11-13 | RVI; FBI; LMA; ABA | 32h |  |
| 16 | 1.3.6 | Suivi | 1d? | 2002-11-20 | 2002-11-20 | 15 |  |  | 2002-11-20 | 2002-11-20 | 1d? | 10d | 4d | start no earlier than 2002-11-20 | RVI; FBI; LMA; ABA | 32h |  |
| 17 | 1.3.7 | Suivi | 1d? | 2002-11-27 | 2002-11-27 | 16 |  |  | 2002-11-27 | 2002-11-27 | 1d? | 6d |  | start no earlier than 2002-11-27 | RVI; FBI; LMA; ABA | 32h |  |
| 18 | 1.4 | **Mise aux normes** | 5d? | 2002-10-21 | 2002-10-25 |  |  |  | 2002-10-21 | 2002-10-25 | 5d? | 30d |  |  |  | 80h |  |
| 19 | 1.4.1 | Mise à la norme prototype admin | 5d? | 2002-10-21 | 2002-10-25 |  |  |  | 2002-10-21 | 2002-10-25 | 5d? | 29d |  | start no earlier than 2002-10-21 | FBI | 40h |  |
| 20 | 1.4.2 | Mise à la norme prototype eval | 5d? | 2002-10-21 | 2002-10-25 |  |  |  | 2002-10-21 | 2002-10-25 | 5d? | 29d |  | start no earlier than 2002-10-21 | RVI | 40h |  |
| 21 | 1.5 | **Codage** | 20d? | 2002-11-04 | 2002-11-29 |  |  |  | 2002-11-04 | 2002-11-22 | 15d? | 5d |  |  |  | 1176h |  |
| 22 | 1.5.1 | Réintégration - Revue | 2d? | 2002-11-04 | 2002-11-05 |  |  |  | 2002-11-04 | 2002-11-05 | 2d? | 22d |  | start no earlier than 2002-11-04 | LMA | 16h |  |
| 23 | 1.5.2 | Définition d'un système de message d'erreur | 5d? | 2002-11-04 | 2002-11-08 |  |  |  | 2002-11-04 | 2002-11-08 | 5d? | 19d |  | start no earlier than 2002-11-04 | FBI | 40h |  |
| 24 | 1.5.3 | Codage Authentification | 5d? | 2002-11-04 | 2002-11-08 |  |  |  |  |  |  | 19d |  | start no earlier than 2002-11-04 | FBI | 40h |  |
| 25 | 1.5.4 | Codage Projet | 5d? | 2002-11-04 | 2002-11-08 |  |  |  |  |  |  | 19d |  | start no earlier than 2002-11-04 | FBI | 40h |  |
| 26 | 1.5.5 | Codage Utilisateur | 5d? | 2002-11-04 | 2002-11-08 |  |  |  |  |  |  | 19d |  | start no earlier than 2002-11-03 | FBI | 40h |  |
| 27 | 1.5.6 | Codage Chargement OT | 5d? | 2002-11-04 | 2002-11-08 |  |  |  |  |  |  | 19d |  | start no earlier than 2002-11-04 | LMA | 40h |  |
| 28 | 1.5.7 | Codage Evaluation Simple | 5d? | 2002-11-04 | 2002-11-08 |  |  |  |  |  |  | 19d |  | start no earlier than 2002-11-03 | RVI | 40h |  |
| 29 | 1.5.8 | Codage Evaluation Ascendante | 5d? | 2002-11-04 | 2002-11-08 |  |  |  |  |  |  | 19d |  | start no earlier than 2002-11-04 | RVI | 40h |  |
| 30 | 1.5.9 | Codage Projet | 5d? | 2002-11-11 | 2002-11-15 |  |  |  |  |  |  | 14d |  | start no earlier than 2002-11-11 | FBI | 40h |  |
| 31 | 1.5.10 | Codage Chargement OT | 5d? | 2002-11-11 | 2002-11-15 |  |  |  |  |  |  | 14d |  | start no earlier than 2002-11-10 | LMA | 40h |  |
| 32 | 1.5.11 | Codage Méthode PDF | 5d? | 2002-11-11 | 2002-11-15 |  |  |  |  |  |  | 14d |  | start no earlier than 2002-11-11 | RVI | 40h |  |
| 33 | 1.5.12 | Codage Choix de méthode | 5d? | 2002-11-11 | 2002-11-15 |  |  |  |  |  |  | 14d |  | start no earlier than 2002-11-11 | RVI | 40h |  |
| 34 | 1.5.13 | Codage Evaluation | 5d? | 2002-11-11 | 2002-11-15 |  |  |  |  |  |  | 14d |  | start no earlier than 2002-11-11 | RVI | 40h |  |
| 35 | 1.5.14 | Intégration, tests, correction des bugs | 5d? | 2002-11-11 | 2002-11-15 |  |  |  |  |  |  | 14d |  | start no earlier than 2002-11-11 | RVI; FBI; LMA | 120h |  |
| 36 | 1.5.15 | Codage Authentification | 5d? | 2002-11-18 | 2002-11-22 |  |  |  |  |  |  | 9d |  | start no earlier than 2002-11-17 | FBI | 40h |  |
| 37 | 1.5.16 | Codage Utilisateur | 5d? | 2002-11-18 | 2002-11-22 |  |  |  |  |  |  | 9d |  | start no earlier than 2002-11-17 | FBI | 40h |  |
| 38 | 1.5.17 | Codage Demander évaluation | 5d? | 2002-11-18 | 2002-11-22 |  |  |  |  |  |  | 9d |  | start no earlier than 2002-11-18 | LMA | 40h |  |
| 39 | 1.5.18 | Codage Consolidation | 5d? | 2002-11-18 | 2002-11-22 |  |  |  |  |  |  | 9d |  | start no earlier than 2002-11-17 | RVI | 40h |  |
| 40 | 1.5.19 | Intégration, tests, et corrections de bugs | 5d? | 2002-11-18 | 2002-11-22 |  |  |  |  |  |  | 9d |  | start no earlier than 2002-11-17 | RVI; FBI; LMA | 120h |  |
| 41 | 1.5.20 | Codage Utilisateur | 5d? | 2002-11-25 | 2002-11-29 |  |  |  |  |  |  | 4d |  | start no earlier than 2002-11-24 | FBI | 40h |  |
| 42 | 1.5.21 | Codage Evaluation | 5d? | 2002-11-25 | 2002-11-29 |  |  |  |  |  |  | 4d |  | start no earlier than 2002-11-25 | RVI | 40h |  |
| 43 | 1.5.22 | Codage classes oubliées | 5d? | 2002-11-25 | 2002-11-29 |  |  |  |  |  |  | 4d |  | start no earlier than 2002-11-25 | LMA; RVI | 80h |  |
| 44 | 1.5.23 | Intégration, tests et corrections des bugs | 5d? | 2002-11-25 | 2002-11-29 |  |  |  |  |  |  | 4d |  | start no earlier than 2002-11-24 | RVI; FBI; LMA | 120h |  |

| ID | WBS | Task | Duration | Start | Finish | Predecessors | Complete | Remaining | Baseline start | Baseline finish | Baseline duration | Total slack | Free slack | Constraint | Resources | Work | Actual work |
| --- | --- | --- | --- | --- | --- | --- | --- | --- | --- | --- | --- | --- | --- | --- | --- | --- | --- |
| 45 | 1.6 | **Déploiement** | 5d? | 2002-11-25 | 2002-11-29 |  |  |  | 2002-11-25 | 2002-11-29 | 5d? | 5d |  |  |  | 40h |  |
| 46 | 1.6.1 | Ecriture script sql d init de la BD | 5d? | 2002-11-25 | 2002-11-29 |  |  |  | 2002-11-25 | 2002-11-29 | 5d? | 4d |  | start no earlier than 2002-11-25 | RVI | 40h |  |
| 47 | 1.7 | **Tests fonctionnels** | 2.5d? | 2002-12-02 | 2002-12-04 |  |  |  |  |  |  | 2.5d |  |  |  | 60h |  |
| 48 | 1.7.1 | Correction des bugs Admin | 2.5d? | 2002-12-02 | 2002-12-04 |  |  |  |  |  |  | 1.5d |  | start no earlier than 2002-12-02 | FBI | 20h |  |
| 49 | 1.7.2 | Correction des bugs Eval | 2.5d? | 2002-12-02 | 2002-12-04 |  |  |  |  |  |  | 1.5d |  | start no earlier than 2002-12-02 | RVI | 20h |  |
| 50 | 1.7.3 | Correction des bugs OT | 2.5d? | 2002-12-02 | 2002-12-04 |  |  |  |  |  |  | 1.5d |  | start no earlier than 2002-12-02 | LMA | 20h |  |
| 51 | 1.8 | **Etude tests** | 5d? | 2002-10-21 A | 2002-10-25 A |  | 100% |  |  |  |  |  |  |  |  | 40h | 40h |
| 52 | 1.8.1 | etude automatisation des tests | 5d? | 2002-10-21 A | 2002-10-25 A |  | 100% |  |  |  |  |  |  | start no earlier than 2002-10-21 | LMA | 40h | 40h |
| 55 | 2 | **Manuel Utilisateur** | 34d? | 2002-10-21 A | 2002-12-05 |  | 17% | 28.14d? |  |  |  | 0d |  |  |  | 224h | 40h |
| 56 | 2.1 | Etude norme 1063 | 5d? | 2002-10-21 A | 2002-10-25 A |  | 100% |  |  |  |  |  |  | start no earlier than 2002-10-21 | RVI | 40h | 40h |
| 57 | 2.2 | Rédaction | 5d? | 2002-11-11 | 2002-11-15 | 56 |  |  |  |  |  | 0d |  | start no earlier than 2002-11-11 | ABA | 40h |  |
| 58 | 2.3 | Mise en évidence du processus de remplissage | 1d? | 2002-11-18 | 2002-11-18 | 57 |  |  |  |  |  | 0d |  | start no earlier than 2002-11-13 | RVI; FBI; LMA; ABA | 32h |  |
| 59 | 2.4 | Rédaction | 4d? | 2002-11-19 | 2002-11-22 | 58 |  |  |  |  |  | 0d |  | start no earlier than 2002-11-18 |  |  |  |
| 60 | 2.5 | Rédaction | 5d? | 2002-11-25 | 2002-11-29 | 59 |  |  |  |  |  | 0d |  |  | ABA | 40h |  |
| 61 | 2.6 | Rédaction | 2d? | 2002-12-02 | 2002-12-03 | 60 |  |  |  |  |  | 0d |  |  | ABA | 16h |  |
| 62 | 2.7 | Etude initialisation | 2.5d? | 2002-11-25 | 2002-11-27 |  |  |  |  |  |  | 7.5d |  | start no earlier than 2002-11-25 | FBI | 20h |  |
| 63 | 2.8 | etude installation | 2.5d? | 2002-11-25 | 2002-11-27 |  |  |  |  |  |  | 7.5d |  | start no earlier than 2002-11-25 | LMA | 20h |  |
| 64 | 2.9 | Verification | 1d? | 2002-12-04 | 2002-12-04 | 61 |  |  |  |  |  | 0d |  | start no earlier than 2002-12-04 | LMA | 8h |  |
| 65 | 2.10 | Validation | 1d? | 2002-12-05 | 2002-12-05 | 64 |  |  |  |  |  | 0d |  |  | ABA | 8h |  |
| 67 | 3 | **Framework Junit** | 20d? | 2002-10-21 A | 2002-11-15 |  | 50% | 10d? |  |  |  | 15d |  |  |  | 80h | 40h |
| 68 | 3.1 | Etude sur methode de tests | 5d? | 2002-10-21 A | 2002-10-25 A |  | 100% |  |  |  |  |  |  | start no earlier than 2002-10-21 | LMA | 40h | 40h |
| 69 | 3.2 | Junit methode de test | 5d? | 2002-11-11 | 2002-11-15 |  |  |  |  |  |  | 15d |  | start no earlier than 2002-11-11 | LMA | 40h |  |
| 71 | 4 | **CR des tests de validation** | 18.5d? | 2002-11-11 | 2002-12-05 |  |  |  |  |  |  | 1.5d |  |  |  | 88h |  |
| 72 | 4.1 | **Scenarios de tests** | 5d? | 2002-11-11 | 2002-11-15 |  |  |  |  |  |  | 15d |  |  |  | 40h |  |
| 73 | 4.1.1 | Correction du PTV d apres remarques CCH | 1d? | 2002-11-11 | 2002-11-11 |  |  |  |  |  |  | 15d | 0d | start no earlier than 2002-11-11 | RVI | 8h |  |
| 74 | 4.1.2 | Rédaction 10 scenarios | 4d? | 2002-11-12 | 2002-11-15 | 73 |  |  |  |  |  | 15d |  |  | ABA | 32h |  |

| ID | WBS | Task | Duration | Start | Finish | Predecessors | Total slack | Free slack | Constraint | Resources | Work |
| --- | --- | --- | --- | --- | --- | --- | --- | --- | --- | --- | --- |
| 75 | 4.2 | **Test** | 2.5d? | 2002-12-02 | 2002-12-04 |  | 1.5d |  |  |  | 40h |
| 76 | 4.2.1 | Effectuer les tests des scenarios | 1.5d? | 2002-12-02 | 2002-12-03 |  | 1.5d | 0d | start no earlier than 2002-12-02 | ABA; LMA | 24h |
| 77 | 4.2.2 | Remplir les fiches | 1d? | 2002-12-03 | 2002-12-04 | 76 | 1.5d | 0d | start no earlier than 2002-12-03 | FBI; RVI | 16h |
| 78 | 4.3 | **Document** | 1d? | 2002-12-04 | 2002-12-05 |  | 1.5d |  |  |  | 8h |
| 79 | 4.3.1 | Rédaction | 1d? | 2002-12-04 | 2002-12-05 | 77 | 1.5d |  | start no earlier than 2002-12-04 | ABA | 8h |
| 81 | 5 | **Présentation Soutenance** | 1d? | 2002-12-03 | 2002-12-03 |  | 3d |  |  |  | 16h |
| 82 | 5.1 | préparation BD | 1d? | 2002-12-03 | 2002-12-03 |  | 3d |  | start no earlier than 2002-12-03 | RVI | 8h |
| 83 | 5.2 | préparation- install logiciel OEDL | 1d? | 2002-12-03 | 2002-12-03 |  | 3d |  | start no earlier than 2002-12-03 | LMA | 8h |
